# AM General

Schedule from MS Project, 2008-02-04 to 2009-11-02.
Trinity Automotive

## Calendars

- Standard: Mon-Fri 08:00-12:00, 13:00-17:00; Sat-Sun off.

## Schedule

| ID | WBS | Task | Type | Duration | Start | Finish | Baseline start | Baseline finish | Baseline duration | Total slack | Constraint |
| --- | --- | --- | --- | --- | --- | --- | --- | --- | --- | --- | --- |
| 1 | 1 | Reciept of Bid Information | milestone | 0d | 2008-02-04 | 2008-02-04 | 2006-01-17 | 2006-01-17 | 0d | 455d | start no earlier than 2008-02-04 |
| 2 | 2 | Proposal Activities |  | 18d | 2008-02-04 | 2008-02-27 | 2006-01-18 | 2006-02-08 | 16d | 437d | finish no earlier than 2008-02-27 |
| 3 | 3 | Proposal Submittal | milestone | 0d | 2008-02-27 | 2008-02-27 | 2006-02-09 | 2006-02-09 | 0d | 438d | start no earlier than 2008-02-27 |
| 4 | 4 | Mahindra International Internal Review / Approval Process |  | 13d | 2008-02-27 | 2008-03-14 | 2006-02-09 | 2006-02-24 | 12d | 425d | finish no earlier than 2008-03-14 |
| 5 | 5 | Contract Award | milestone | 0d | 2008-03-17 | 2008-03-17 | 2006-04-10 | 2006-04-10 | 0d | 425d | start no earlier than 2008-03-17 |
| 6 | 6 | Detailed Layout and Process Engineering |  | 25d | 2008-03-17 | 2008-04-18 | 2006-04-11 | 2006-04-24 | 10d | 400d | finish no earlier than 2008-04-18 |
| 7 | 7 | Process Layout Frozen | milestone | 0d | 2008-04-18 | 2008-04-18 | 2006-04-12 | 2006-04-12 | 0d | 401d | start no earlier than 2008-04-18 |
| 8 | 8 | Building Coordination Activities |  | 40d | 2008-04-21 | 2008-06-13 | 2006-04-17 | 2006-06-09 | 40d | 360d | finish no earlier than 2008-06-13 |
| 9 | 9 | Building Engineering and Design |  | 90d | 2008-05-12 | 2008-09-12 |  |  |  | 295d | finish no earlier than 2008-09-12 |
| 10 | 10 | Building Construction |  | 160d | 2008-07-14 | 2009-02-20 |  |  |  | 180d | finish no earlier than 2009-02-20 |
| 11 | 11 | Process Equipment Engineering / Detailed Design |  | 155d | 2008-04-21 | 2008-11-21 | 2006-04-12 | 2006-07-07 | 63d | 245d | finish no earlier than 2008-11-21 |
| 12 | 12 | Process Equipment Procurement & Fabrication |  | 170d | 2008-07-14 | 2009-03-06 | 2006-05-15 | 2006-09-01 | 80d | 170d | finish no earlier than 2009-03-06 |
| 13 | 13 | Process Equipment Installation |  | 185d | 2008-12-15 | 2009-08-28 | 2006-07-31 | 2006-12-01 | 90d | 45d | finish no earlier than 2009-08-28 |
| 14 | 14 | Start-Up / Debug / Training |  | 45d | 2009-08-03 | 2009-10-02 | 2006-11-20 | 2006-12-15 | 20d | 20d | finish no earlier than 2009-10-02 |
| 15 | 15 | Start of Pre-Production Trials |  | 25d | 2009-09-28 | 2009-10-30 | 2006-12-14 | 2006-12-29 | 12d | 0d | finish no earlier than 2009-10-30 |
| 16 | 16 | Production Launch | milestone | 0d | 2009-11-02 | 2009-11-02 | 2007-01-02 | 2007-01-02 | 0d | 0d | start no earlier than 2009-11-02 |
| 18 | 17 | Building Engineering and Design |  | 90d | 2008-05-12 | 2008-09-12 | 2005-10-03 | 2005-10-28 | 20d | 295d | finish no earlier than 2008-09-12 |
| 19 | 18 | Site Preparation |  | 45d | 2008-06-02 | 2008-08-01 |  |  |  | 325d | finish no earlier than 2008-08-01 |
| 20 | 19 | Building Construction |  | 160d | 2008-07-14 | 2009-02-20 |  |  |  | 180d | finish no earlier than 2009-02-20 |
| 21 | 20 | Building Beneficial Occupancy | milestone | 0d | 2008-12-15 | 2008-12-15 |  |  |  | 230d | start no earlier than 2008-12-15 |
| 22 | 21 | Building Completion | milestone | 0d | 2009-02-20 | 2009-02-20 |  |  |  | 181d | start no earlier than 2009-02-20 |
| 24 | 22 | Phosphate / E-Coat Engineering & Design |  | 105d | 2008-04-21 | 2008-09-12 |  |  |  | 295d | finish no earlier than 2008-09-12 |
| 25 | 23 | Phosphate / E-Coat Procurement & Fabrication |  | 150d | 2008-07-14 | 2009-02-06 |  |  |  | 190d | finish no earlier than 2009-02-06 |
| 26 | 24 | Phosphate / E-Coat Installation |  | 140d | 2008-12-15 | 2009-06-26 |  |  |  | 90d | finish no earlier than 2009-06-26 |
| 27 | 25 | Phosphate / E-Coat Start-Up / Debug / Training |  | 45d | 2009-08-03 | 2009-10-02 |  |  |  | 20d | finish no earlier than 2009-10-02 |
| 28 | 26 | Phosphate / E-Coat Pre-Production Trials |  | 25d | 2009-09-28 | 2009-10-30 |  |  |  | 0d | finish no earlier than 2009-10-30 |
| 30 | 27 | Spraybooths/ASH/Sludge/ Engineering & Design |  | 145d | 2008-06-02 | 2008-12-19 | 2005-09-06 | 2005-11-01 | 41d | 225d | finish no earlier than 2008-12-19 |
| 31 | 28 | Spraybooths/ASH/Sludge Procurement & Fabrication |  | 135d | 2008-09-29 | 2009-04-03 | 2005-10-03 | 2005-12-30 | 65d | 150d | finish no earlier than 2009-04-03 |
| 32 | 29 | Spraybooths/ASH/Sludge Installation |  | 135d | 2009-02-02 | 2009-08-07 | 2005-11-01 | 2006-01-26 | 63d | 60d | finish no earlier than 2009-08-07 |
| 33 | 30 | Spraybooths/ASH/Sludge Start-Up / Debug / Training |  | 45d | 2009-08-03 | 2009-10-02 | 2006-01-23 | 2006-02-10 | 15d | 20d | finish no earlier than 2009-10-02 |
| 34 | 31 | Spraybooths/ASH/Sludge Pre-Production Trials |  | 25d | 2009-09-28 | 2009-10-30 | 2006-02-08 | 2006-03-10 | 23d | 0d | finish no earlier than 2009-10-30 |
| 36 | 32 | Cure Ovens / Coolers Engineering & Design |  | 130d | 2008-08-04 | 2009-01-30 |  |  |  | 195d | start no earlier than 2008-08-04 |
| 37 | 33 | Cure Ovens / Coolers Procurement & Fabrication |  | 130d | 2008-11-17 | 2009-05-15 |  |  |  | 120d | finish no earlier than 2009-05-15 |
| 38 | 34 | Cure Ovens / Coolers Installation |  | 100d | 2009-03-16 | 2009-07-31 |  |  |  | 65d | finish no earlier than 2009-07-31 |
| 39 | 35 | Cure Ovens / Coolers Start-Up / Debug / Training |  | 45d | 2009-08-03 | 2009-10-02 |  |  |  | 20d | finish no earlier than 2009-10-02 |
| 40 | 36 | Cure Ovens / Coolers Pre-Production Trials |  | 25d | 2009-09-28 | 2009-10-30 |  |  |  | 0d | finish no earlier than 2009-10-30 |
| 42 | 37 | Conveyor Engineering & Design |  | 105d | 2008-11-03 | 2009-03-27 | 2005-09-26 | 2005-11-18 | 40d | 155d | finish no earlier than 2009-03-27 |
| 43 | 38 | Conveyor Procurement & Fabrication |  | 95d | 2009-02-23 | 2009-07-03 | 2005-10-24 | 2005-12-30 | 50d | 85d | finish no earlier than 2009-07-03 |
| 44 | 39 | Conveyor Installation |  | 80d | 2009-04-27 | 2009-08-14 | 2005-12-28 | 2006-02-17 | 38d | 55d | finish no earlier than 2009-08-14 |
| 45 | 40 | Conveyor Start-Up / Debug / Training |  | 40d | 2009-08-10 | 2009-10-02 | 2006-02-20 | 2006-03-03 | 10d | 20d | finish no earlier than 2009-10-02 |
| 46 | 41 | Conveyor Pre-Production Trials |  | 25d | 2009-09-28 | 2009-10-30 | 2006-03-06 | 2006-03-20 | 11d | 0d | finish no earlier than 2009-10-30 |
| 48 | 42 | Robots / Application Equipment Engineering and Design |  | 75d | 2008-11-17 | 2009-02-27 |  |  |  | 175d | finish no earlier than 2009-02-27 |
| 49 | 43 | Robots / Application Equipment Procurement & Fabrication |  | 105d | 2009-02-16 | 2009-07-10 |  |  |  | 80d | finish no earlier than 2009-07-10 |
| 50 | 44 | Robots / Application Equipment Installation |  | 35d | 2009-06-29 | 2009-08-14 |  |  |  | 55d | start no earlier than 2009-06-29 |
| 51 | 45 | Robots / Application Equipment Start-Up / Debug / Training |  | 40d | 2009-08-10 | 2009-10-02 |  |  |  | 20d | finish no earlier than 2009-10-02 |
| 52 | 46 | Robots / Application Equipment Pre-Production Trials |  | 25d | 2009-09-28 | 2009-10-30 |  |  |  | 0d | finish no earlier than 2009-10-30 |
| 54 | 47 | Paint Mix & Circ Engineering & Design |  | 65d | 2008-12-01 | 2009-02-27 | 2005-09-26 | 2005-11-04 | 30d | 175d | finish no earlier than 2009-02-27 |
| 55 | 48 | Paint Mix & Circ Procurement & Fabrication |  | 81d | 2009-02-23 | 2009-06-15 | 2005-10-24 | 2006-01-06 | 55d | 99d | start no earlier than 2009-02-23 |
| 56 | 49 | Paint Mix & Circ Installation |  | 55d | 2009-05-25 | 2009-08-07 | 2005-12-27 | 2006-02-17 | 39d | 60d | finish no earlier than 2009-08-07 |
| 57 | 50 | Paint Mix & Circ Start-Up / Debug / Training |  | 45d | 2009-08-03 | 2009-10-02 | 2006-02-15 | 2006-03-03 | 13d | 20d | finish no earlier than 2009-10-02 |
| 58 | 51 | Paint Mix & Circ Pre-Production Trials |  | 25d | 2009-09-28 | 2009-10-30 | 2006-03-01 | 2006-03-20 | 14d | 0d | finish no earlier than 2009-10-30 |
| 60 | 52 | Misc. Booths / Decks / Enclosures Engineering & Design |  | 70d | 2008-12-22 | 2009-03-27 | 2005-10-10 | 2005-11-23 | 33d | 155d | finish no earlier than 2009-03-27 |
| 61 | 53 | Misc. Booths / Decks / Enclosures Procurement & Fabrication |  | 85d | 2009-02-16 | 2009-06-12 | 2005-11-01 | 2006-01-06 | 49d | 100d | finish no earlier than 2009-06-12 |
| 62 | 54 | Misc. Booths / Decks / Enclosures Installation |  | 55d | 2009-05-25 | 2009-08-07 | 2005-12-12 | 2005-12-30 | 15d | 60d | finish no earlier than 2009-08-07 |
| 63 | 55 | Misc. Booths / Decks / Enclosures Start-Up / Debug / Training |  | 40d | 2009-08-10 | 2009-10-02 | 2005-12-26 | 2005-12-30 | 5d | 20d | start no earlier than 2009-08-10 |
| 64 | 56 | Misc. Booths / Decks / Enclosures Pre-Production Trials |  | 25d | 2009-09-28 | 2009-10-30 | 2005-12-28 | 2006-01-03 | 5d | 0d | finish no earlier than 2009-10-30 |
| 66 | 57 | Paint System Production Launch | milestone | 0d | 2009-11-02 | 2009-11-02 | 2006-03-21 | 2006-03-21 | 0d | 0d | start no earlier than 2009-11-02 |
